Schedule from MS Project, 2007-10-02 to 2007-11-28.
_

## Calendars

- Estándar: Mon off; Tue-Fri 12:00-14:00, 16:30-18:15; Sat-Sun off. Exceptions (off unless hours are given): 2007-10-12, 2007-11-01 to 2007-11-02.
- Calendario de clase: Mon off; Tue-Fri 16:30-18:15; Sat-Sun off. Exceptions (off unless hours are given): 2007-10-12, 2007-11-01 to 2007-11-02.

## Resources

| Resource |
| --- |
| profesor |
| técnico DPE |

## Schedule

| ID | WBS | Task | Duration | Start | Finish | Predecessors | Baseline start | Baseline finish | Baseline duration | Total slack | Free slack | Calendar | Resources | Work |
| --- | --- | --- | --- | --- | --- | --- | --- | --- | --- | --- | --- | --- | --- | --- |
| 1 | 1 | presentación | 1h | 2007-10-02 | 2007-10-02 |  | 2007-10-02 | 2007-10-02 | 1h | 0d |  |  | profesor | 1h |
| 2 | 2 | **estudios previos** | 4.62d | 2007-10-02 | 2007-10-19 | 1 | 2007-10-02 | 2007-10-19 | 4.62d | 0d |  |  |  | 21h |
| 3 | 2.1 | estudio del PIC16F84 | 8h | 2007-10-02 | 2007-10-10 |  | 2007-10-02 | 2007-10-10 | 8h | 0d |  |  | profesor | 8h |
| 4 | 2.2 | práctica PIC16F84 | 4h | 2007-10-10 | 2007-10-16 | 3 | 2007-10-10 | 2007-10-16 | 4h | 0.56d |  | Calendario de clase | técnico DPE | 4h |
| 5 | 2.3 | estudio del PIC16F88 | 4h | 2007-10-10 | 2007-10-16 | 3 | 2007-10-10 | 2007-10-16 | 4h | 0d |  |  | profesor | 4h |
| 6 | 2.4 | estudio de MS-Project | 3h | 2007-10-17 | 2007-10-19 | 7 | 2007-10-17 | 2007-10-19 | 3h | 9.81d |  |  | profesor | 3h |
| 7 | 2.5 | estudio de la conversión A/D | 2h | 2007-10-16 | 2007-10-17 | 5 | 2007-10-16 | 2007-10-17 | 2h | 9.81d | 0d |  | profesor | 2h |
| 8 | 3 | **realización del hardware** | 8.47d | 2007-10-16 | 2007-11-20 | 5 | 2007-10-16 | 2007-11-21 | 8.94d | 0d |  |  |  | 38h |
| 9 | 3.1 | **realización del prototipo en wrapping** | 5.75d | 2007-10-16 | 2007-11-08 |  | 2007-10-16 | 2007-11-09 | 6.19d | 0d |  |  |  | 26h |
| 10 | 3.1.1 | diseño del sistema | 8h | 2007-10-16 | 2007-10-18 |  | 2007-10-16 | 2007-10-18 | 8h | 0d |  |  | técnico DPE | 8h |
| 11 | 3.1.2 | montaje | 2h | 2007-10-18 | 2007-10-19 | 10 | 2007-10-18 | 2007-10-19 | 2h | 0d |  | Calendario de clase | técnico DPE | 2h |
| 12 | 3.1.3 | pruebas del circuito básico | 2h | 2007-10-19 | 2007-10-23 | 11 | 2007-10-19 | 2007-10-23 | 2h | 0d |  | Calendario de clase | técnico DPE | 2h |
| 13 | 3.1.4 | pruebas de pulsadores | 3h | 2007-10-24 | 2007-10-25 | 12 | 2007-10-24 | 2007-10-25 | 3h | 0d |  | Calendario de clase | técnico DPE | 3h |
| 14 | 3.1.5 | pruebas del bloque de entrada | 3h | 2007-10-25 | 2007-10-30 | 13 | 2007-10-25 | 2007-10-30 | 3h | 0d |  | Calendario de clase | técnico DPE | 3h |
| 15 | 3.1.6 | pruebas de medición de la señal | 4h | 2007-10-30 | 2007-11-06 | 14, 25 | 2007-10-30 | 2007-11-06 | 4h | 0d |  | Calendario de clase | técnico DPE | 4h |
| 16 | 3.1.7 | pruebas globales | 4h | 2007-11-06 | 2007-11-08 | 23, 15 | 2007-11-07 | 2007-11-09 | 4h | 0d |  | Calendario de clase | técnico DPE | 4h |
| 17 | 3.2 | **realización del circuito impreso** | 2.72d | 2007-11-09 | 2007-11-20 | 9, 23 | 2007-11-09 | 2007-11-21 | 2.75d | 0d |  |  |  | 12h |
| 18 | 3.2.1 | diseño de la placa | 4h | 2007-11-09 | 2007-11-13 |  | 2007-11-09 | 2007-11-13 | 4h | 0.22d |  |  | técnico DPE | 4h |
| 19 | 3.2.2 | realización de la placa | 2h | 2007-11-13 | 2007-11-14 | 18 | 2007-11-14 | 2007-11-15 | 2h | 0d |  | Calendario de clase | técnico DPE | 2h |
| 20 | 3.2.3 | comprobación de la placa | 1h | 2007-11-14 | 2007-11-14 | 19 | 2007-11-15 | 2007-11-15 | 1h | 0d |  | Calendario de clase | técnico DPE | 1h |
| 21 | 3.2.4 | montaje de componentes | 1h | 2007-11-14 | 2007-11-15 | 20 | 2007-11-15 | 2007-11-16 | 1h | 0d |  | Calendario de clase | técnico DPE | 1h |
| 22 | 3.2.5 | pruebas de la placa | 4h | 2007-11-15 | 2007-11-20 | 21 | 2007-11-16 | 2007-11-21 | 4h | 0d |  | Calendario de clase | técnico DPE | 4h |
| 23 | 4 | **realización del software** | 3.25d | 2007-10-18 | 2007-10-31 | 10, 4 | 2007-10-18 | 2007-11-07 | 4.19d | 0.5d |  |  |  | 18h |
| 24 | 4.1 | diseño de alto nivel | 2h | 2007-10-18 | 2007-10-19 |  | 2007-10-18 | 2007-10-19 | 2h | 0.22d | 0d |  | técnico DPE | 2h |
| 25 | 4.2 | rutinas de medición de la señal | 8h | 2007-10-19 | 2007-10-24 | 24 | 2007-10-19 | 2007-10-24 | 8h | 0.5d | 0d |  | técnico DPE | 8h |
| 26 | 4.3 | ensamblaje y simulación | 8h | 2007-10-24 | 2007-10-31 | 25 | 2007-10-26 | 2007-11-07 | 8h | 0.25d |  | Calendario de clase | técnico DPE | 8h |

| ID | WBS | Task | Duration | Start | Finish | Predecessors | Baseline start | Baseline finish | Baseline duration | Total slack | Resources | Work |
| --- | --- | --- | --- | --- | --- | --- | --- | --- | --- | --- | --- | --- |
| 27 | 5 | **realización de la documentación** | 2.25d | 2007-11-20 | 2007-11-28 | 8, 23 | 2007-11-21 | 2007-11-29 | 2.25d | 0d |  | 20h |
| 28 | 5.1 | memoria descriptiva | 6h | 2007-11-20 | 2007-11-22 |  | 2007-11-21 | 2007-11-23 | 6h | 0d | técnico DPE | 6h |
| 29 | 5.2 | diseño de hardware | 4h | 2007-11-22 | 2007-11-23 | 28 | 2007-11-23 | 2007-11-27 | 4h | 0d | técnico DPE | 4h |
| 30 | 5.3 | diseño de software | 4h | 2007-11-23 | 2007-11-27 | 29 | 2007-11-27 | 2007-11-28 | 4h | 0d | técnico DPE | 4h |
| 31 | 5.4 | planos | 1h | 2007-11-23 | 2007-11-23 | 29 | 2007-11-27 | 2007-11-27 | 1h | 0.88d | técnico DPE | 1h |
| 32 | 5.5 | presupesto | 1h | 2007-11-27 | 2007-11-27 | 29, 30 | 2007-11-28 | 2007-11-28 | 1h | 0.38d | técnico DPE | 1h |
| 33 | 5.6 | manual del usuario | 2h | 2007-11-28 | 2007-11-28 | 34 | 2007-11-29 | 2007-11-29 | 2h | 0d | técnico DPE | 2h |
| 34 | 5.7 | manual del S.A.T. | 2h | 2007-11-27 | 2007-11-28 | 29, 30 | 2007-11-28 | 2007-11-29 | 2h | 0d | técnico DPE | 2h |
